# Proyecto de Ejemplo 1

Schedule from MS Project, 2024-10-01 to 2026-04-14, 6 hours a day.

## Calendars

- Calendario L-Mi-V: Mon 08:00-12:00, 13:00-15:00; Tue off; Wed 08:00-12:00, 13:00-15:00; Thu off; Fri 08:00-12:00, 13:00-15:00; Sat-Sun off. Exceptions (off unless hours are given): 2025-01-01 (Año Nuevo), 2025-01-06 (Dia de Reyes), 2025-01-21 (Virgen De La Altagracia), 2025-02-27 (Independencia Nacional), 2025-04-17 (Jueves Santos), 2025-04-18 (Viernes santos), 2025-05-01 (Dia Del Trabajador), 2025-06-19 (Corpus Christi), 2025-09-24 (Dia de La Mercedes), 2025-11-10 (Dia de La Constitucion), 2025-12-24 (Noche Buena), 2025-12-25 (Navidad), 2025-12-31 (Fin de Año), 2026-01-01 (Año Nuevo), 2026-01-06 (Dia de Reyes), 2026-01-21 (Dia de La Altagracia), 2026-01-26 (Juan Pablo Duarte), 2026-02-27 (Independencia), 2026-04-02 (Jueves Santos), 2026-04-03 (Viernes Santos).
- Calendario Ma y J: Mon off; Tue 08:00-12:00, 13:00-15:00; Wed off; Thu 08:00-12:00, 13:00-15:00; Fri-Sun off. Exceptions (off unless hours are given): 2025-01-01 (Año Nuevo), 2025-01-06 (Dia de Reyes), 2025-01-21 (Virgen De La Altagracia), 2025-02-27 (Independencia Nacional), 2025-04-17 (Jueves Santos), 2025-04-18 (Viernes Santos), 2025-05-01 (Dia Del Trabajador), 2025-06-19 (Corpus Christi), 2025-08-16 (Dia de la Restauracion), 2025-09-24 (Dia de Las Mercedes), 2025-11-10 (Dia de la Constitucion), 2025-12-24 (Noche Buena), 2025-12-25 (Navidad), 2025-12-31 (Fin de Año), 2026-01-01 (Año Nuevo), 2026-01-06 (Dia de Reyes), 2026-01-21 (Dia de La Altagracia), 2026-01-26 (Dia de Duarte), 2026-02-27 (Independencia), 2026-04-02 (Jueves Santos), 2026-04-03 (Viernes Santos).
- Estándar con día feriados: Mon-Fri 09:00-13:00, 15:00-19:00; Sat-Sun off. Exceptions (off unless hours are given): 2025-01-01 (Año Nuevo), 2025-01-06 (Dia de Reyes), 2025-01-21 (Virgen de la Altagracia), 2025-02-27 (Independencia Nacional), 2025-04-17 (Jueves Santos), 2025-04-18 (Viernes Santos), 2025-05-01 (Dia del Trabajador), 2025-06-19 (Corpus Christi), 2025-09-24 (Dia de Las Mercedes), 2025-11-10 (Dia de la Constitucion), 2025-12-24 (Noche Buena), 2025-12-25 (Navidad), 2025-12-31 (Fin de Año), 2026-01-01 (Año Nuevo), 2026-01-06 (Dis de Reyes), 2026-01-21 (Virgen de La Altagracia), 2026-01-26 to 2026-01-27 (Dia de Juan Pablo Duarte), 2026-02-27 (Independencia Nacional), 2026-04-02 (Jueves Santos), 2026-04-03 (Viernes Santos).

## Resources

| Resource |
| --- |
| Hoyero 1 |
| Hoyero 2 |
| Hoyero 3 |
| Hoyero 4 |
| Hoyero 5 |
| Hoyero 6 |
| Hoyero 7 |
| Hoyero 8 |
| Hoyero 9 |
| Hoyero 10 |
| Grúa 2 |
| Grúa 3 |
| Grúa 4 |
| Grúa 5 |
| Canasto 1 |
| Canasto 2 |
| Canasto 3 |
| Canasto 4 |
| Canasto 5 |
| Canasto 6 |
| Canasto 7 |
| Canasto 8 |
| Canasto 9 |
| Canasto 10 |
| Brigada de Normalización 1 |
| Brigada de Normalización 2 |
| Brigada de Normalización 3 |
| Brigada de Normalización 4 |
| Brigada de Normalización 5 |
| Supervisor 1 |
| Supervisor 2 |
| Supervisor 3 |
| Supervisor 4 |
| Supervisor 5 |
| Supervisor 6 |
| Supervisor 7 |
| Supervisor 8 |
| Supervisor 9 |
| Supervisor 10 |
| Capataz 1 |
| Capataz 2 |
| Capataz 3 |
| Capataz 4 |
| Capataz 5 |
| Capataz 6 |
| Capataz 7 |
| Capataz 8 |
| Capataz 9 |
| Capataz 10 |
| Brigada de Poda 1 |
| Brigada de Poda 2 |
| Brigada de Poda 3 |
| Brigada de Poda 4 |
| Brigada de Poda 5 |
| Brigada de Poda 6 |
| Brigada de Poda 7 |
| Brigada de Poda 8 |
| Brigada de Poda 9 |
| Brigada de Poda 10 |
| Brigada Ligera 1 |
| Brigada Ligera 2 |
| Brigada Ligera 3 |
| Brigada Ligera 4 |
| Brigada Ligera 5 |
| Brigada Ligera 6 |
| Brigada Ligera 7 |
| Brigada Ligera 8 |
| Brigada Ligera 9 |
| Brigada Ligera 10 |
| Hoyero 1 A |
| Hoyero 2 B |
| Hoyero 3 C |
| Hoyero 4 D |
| Hoyero 5 E |
| Hoyero 6 F |
| Hoyero 7 G |
| Hoyero 8 H |
| Hoyero 9 I |
| Hoyero 10 J |
| Grúa 1 A |
| Grúa 2 B |
| Grúa 3 C |
| Grúa 4 D |
| Grúa 5 E |
| Canasto 1 A |
| Canasto 2 B |
| Canasto 3 C |
| Canasto 4 D |
| Canasto 5 E |
| Canasto 6 F |
| Canasto 7 G |
| Canasto 8 H |
| Canasto 9 I |
| Canasto 10 J |
| Brigada de Normalización 1 A |
| Brigada de Normalización 2 B |
| Brigada de Normalización 3 C |
| Brigada de Normalización 4 D |
| Brigada de Normalización 5 E |
| Brigada de Normalización 6 F |
| Brigada de Normalización 7 G |
| Brigada de Normalización 8 H |
| Brigada de Normalización 9 I |
| Brigada de Normalización 10 J |
| Supervisor 1 A |
| Supervisor 2 B |
| Supervisor 3 C |
| Supervisor 4 D |
| Supervisor 5 E |
| Supervisor 6 F |
| Supervisor 7 G |
| Supervisor 8 H |
| Supervisor 9 I |
| Supervisor 10 J |
| Capataz 1 A |
| Capataz 2 B |
| Capataz 3 C |
| Capataz 4 D |
| Capataz 5 E |
| Capataz 6 F |
| Capataz 7 G |
| Capataz 8 H |
| Capataz 9 I |
| Capataz 10 J |
| Brigada de Poda 1 A |
| Brigada de Poda 2 B |
| Brigada de Poda 3 C |
| Brigada de Poda 4 D |
| Brigada de Poda 5 E |
| Brigada de Poda 6 F |
| Brigada de Poda 7 G |
| Brigada de Poda 8 H |
| Brigada de Poda 9 I |
| Brigada de Poda 10 J |
| Brigada Ligera 1 A |
| Brigada Ligera 2 B |
| Brigada Ligera 3 C |
| Brigada Ligera 4 D |
| Brigada Ligera 5 E |
| Brigada Ligera 6 F |
| Brigada Ligera 7 G |
| Brigada Ligera 8 H |
| Brigada Ligera 9 I |
| Brigada Ligera 10 J |
| Hoyero 11 |
| Hoyero 12 |
| Hoyero 13 |
| Hoyero 14 |
| Hoyero 15 |
| Grúa 1 |
| Hoyero 11 K |
| Hoyero 12 L |
| Hoyero 13 M |
| Hoyero 14 N |
| Hoyero 15 Ñ |

## Schedule

| ID | WBS | Task | Duration | Start | Finish | Predecessors | Total slack | Free slack | Constraint | Calendar | Resources | Work | Días Calendario | Cantidad |
| --- | --- | --- | --- | --- | --- | --- | --- | --- | --- | --- | --- | --- | --- | --- |
| 1 | 1 | **Proyecto Lote-05 La Bija Y La Angelina** | 506d | 2024-10-01 | 2026-04-14 |  | 0d |  |  | Estándar con día feriados |  | 20808h | 561días |  |
| 2 | 1.1 | **Preparativos previos Obras** | 44d | 2024-10-01 | 2024-11-14 |  | 2.67d |  |  | Estándar con día feriados |  |  | 45días |  |
| 3 | 1.1.1 | Reuniones con Contratista | 5d | 2024-10-01 | 2024-10-04 |  | 412.33d | 0d | start no earlier than 2024-10-01 | Estándar con día feriados |  |  | 4días |  |
| 4 | 1.1.2 | Revisiones adicionales de Ingenieria-Replanteo | 30d | 2024-10-07 | 2024-11-06 | 3FS+1d | 412.33d | 0d |  | Estándar con día feriados |  |  | 31días |  |
| 5 | 1.1.3 | Firma Minuta | 7d | 2024-11-07 | 2024-11-14 | 4FS+1d | 503.33d |  |  | Estándar con día feriados |  |  | 8días |  |
| 6 | 1.1.4 | Obtension Recursos Contratista | 30d | 2024-10-07 | 2024-11-06 |  | 512d |  | start no earlier than 2024-10-07 | Estándar con día feriados |  |  | 31días |  |
| 7 | 1.1.5 | Gestion de Materiales y Revision contra Fichas Tecnicas | 21d | 2024-10-07 | 2024-10-29 | 3FS+1d | 520.33d |  |  | Estándar con día feriados |  |  | 23días |  |
| 8 | 1.2 | **Suministro Materiales** | 119d | 2024-10-17 | 2025-02-24 |  | 371d |  |  | Estándar con día feriados |  |  | 131días |  |
| 9 | 1.2.1 | Suministro Postes | 90d | 2024-10-17 | 2025-01-23 | 4SS+10d | 412.33d | 0d |  | Estándar con día feriados |  |  | 99días |  |
| 10 | 1.2.2 | Suministro Armados | 90d | 2024-10-31 | 2025-02-06 | 9SS+14d | 412.33d | 0d |  | Estándar con día feriados |  |  | 99días |  |
| 11 | 1.2.3 | Suministro Tendido (Cables) | 90d | 2024-11-15 | 2025-02-24 | 10SS+15d | 412.33d | 0d |  | Estándar con día feriados |  |  | 102días |  |
| 12 | 1.2.4 | Suministro Transformadores | 90d | 2024-11-15 | 2025-02-24 | 11SS | 412.33d |  |  | Estándar con día feriados |  |  | 102días |  |
| 13 | 1.2.5 | Suministro Equipos Proteccion | 90d | 2024-11-15 | 2025-02-24 | 11SS | 412.33d |  |  | Estándar con día feriados |  |  | 102días |  |
| 14 | 1.2.6 | Suminiostro Alumbrado Publico | 90d | 2024-11-15 | 2025-02-24 | 11SS | 412.33d |  |  | Estándar con día feriados |  |  | 102días |  |
| 15 | 1.2.7 | Suministro Acometida y medidores | 90d | 2024-11-15 | 2025-02-24 | 11SS | 412.33d |  |  | Estándar con día feriados |  |  | 102días |  |
| 16 | 1.3 | **Ejecucion de Obras** | 209d | 2024-11-18 | 2026-04-14 |  | 0d |  |  |  |  | 20808h | 513días |  |
| 17 | 1.3.1 | **Poligono 1** | 79d | 2024-11-18 | 2025-05-26 |  | 23d |  |  |  |  | 5004h | 190días |  |
| 18 | 1.3.1.1 | Excavaciones | 16d | 2024-11-18 | 2024-12-23 | 5FS+1d | 23d | 0d |  |  | Hoyero 2; Hoyero 3; Hoyero 4; Hoyero 5; Hoyero 6; Hoyero 7; Hoyero 8; Hoyero 9; Hoyero 1; Hoyero 10; Hoyero 11; Hoyero 12; Hoyero 13; Hoyero 14; Hoyero 15 | 1440h | 36días | 942 |
| 19 | 1.3.1.2 | Izado de postes | 15d | 2024-11-18 | 2024-12-20 | 18SS | 23d | 0d |  |  | Grúa 2; Grúa 3; Grúa 1; Grúa 4; Grúa 5 | 450h | 33días | 509 |
| 20 | 1.3.1.3 | Cimentaciones | 6d | 2024-12-11 | 2024-12-23 | 19SS+10d | 193d |  |  |  | Brigada Ligera 1; Brigada Ligera 2; Brigada Ligera 3 | 108h | 13días | 94 |
| 21 | 1.3.1.4 | Retenidas | 11d | 2024-12-02 | 2024-12-25 | 19SS+6d | 192d |  |  |  | Canasto 1; Brigada Ligera 4; Brigada Ligera 5; Brigada Ligera 6; Brigada Ligera 7 | 330h | 24días | 433 |
| 22 | 1.3.1.5 | Armados MT y BT | 13d | 2024-11-29 | 2024-12-27 | 19SS+5d | 23d | 0d |  |  | Canasto 2; Canasto 3; Canasto 4; Canasto 5; Canasto 6; Canasto 7 | 468h | 29días | 641 |
| 23 | 1.3.1.6 | Tendido de Conductor MT y BT | 18d | 2025-01-03 | 2025-02-14 | 22FS+1d | 23d | 0d |  |  | Canasto 2; Canasto 3; Canasto 1; Canasto 4; Canasto 5; Canasto 6 | 648h | 43días | 37,032 |
| 24 | 1.3.1.7 | Puesta a Tierra | 7d | 2025-02-17 | 2025-03-03 | 23 | 165d |  |  |  | Canasto 1; Canasto 2; Canasto 3; Canasto 4 | 168h | 15días | 299 |
| 25 | 1.3.1.8 | Conexiones y Jumper | 9d | 2025-02-17 | 2025-03-07 | 23 | 23d | 0d |  |  | Canasto 5; Canasto 6; Canasto 7; Canasto 8 | 216h | 19días | 342 |
| 26 | 1.3.1.9 | Transformadores | 5d | 2025-03-05 | 2025-03-14 | 25SS+7d | 23d | 0d |  |  | Grúa 2; Canasto 1; Canasto 2; Grúa 1; Grúa 3; Grúa 4; Canasto 3; Canasto 4 | 240h | 10días | 60 |
| 27 | 1.3.1.10 | Alumbrado Público | 8d | 2025-03-10 | 2025-03-26 | 25 | 143d | 0d |  |  | Canasto 5; Canasto 6; Canasto 7; Canasto 8 | 192h | 17días | 491 |
| 28 | 1.3.1.11 | Etiquetas CT | 2d | 2025-03-17 | 2025-03-19 | 26 | 23d | 0d |  |  | Canasto 1; Canasto 2 | 24h | 3días | 66 |
| 29 | 1.3.1.12 | Totalizadores | 6d | 2025-03-21 | 2025-04-02 | 28 | 23d | 0d |  |  | Canasto 1; Canasto 2; Canasto 3; Canasto 4 | 144h | 13días | 66 |
| 30 | 1.3.1.13 | Acometida | 22d | 2025-03-24 | 2025-05-14 | 28FS+1d | 130d | 0d |  |  | Brigada de Normalización 2; Brigada de Normalización 1 | 264h | 52días | 869 |
| 31 | 1.3.1.14 | Remoción | 13d | 2025-04-28 | 2025-05-26 | 30SS+14d | 130d |  |  |  | Grúa 2; Canasto 7; Grúa 1; Canasto 8 | 312h | 29días | 1,273 |

Notes:
- 19: No se le asigna canasto, pero requiere uno para apertura y cierre de seccionador
- 23: Con una grua es suficiente para darle apoyo a los canastos.

| ID | WBS | Task | Duration | Start | Finish | Predecessors | Total slack | Free slack | Calendar | Resources | Work | Días Calendario | Cantidad |
| --- | --- | --- | --- | --- | --- | --- | --- | --- | --- | --- | --- | --- | --- |
| 33 | 1.3.2 | **Poligono 2** | 92d | 2024-11-21 | 2025-10-23 |  | 0d |  | Calendario Ma y J |  | 2820h | 337días |  |
| 34 | 1.3.2.1 | Excavaciones | 6d | 2024-11-21 | 2024-12-10 | 5FS+1d | 0d |  | Calendario Ma y J | Hoyero 2 B; Hoyero 3 C; Hoyero 4 D; Hoyero 5 E; Hoyero 6 F; Hoyero 7 G; Hoyero 8 H; Hoyero 9 I; Hoyero 10 J; Hoyero 1 A; Hoyero 11 K; Hoyero 12 L; Hoyero 13 M; Hoyero 14 N; Hoyero 15 Ñ | 540h | 20días | 372 |
| 35 | 1.3.2.2 | Izado de postes | 6d | 2024-11-21 | 2024-12-10 | 34SS | 0d |  | Calendario Ma y J | Grúa 2 B; Grúa 3 C; Grúa 1 A; Grúa 4 D; Grúa 5 E | 180h | 20días | 216 |
| 36 | 1.3.2.3 | Cimentaciones | 7d | 2024-11-26 | 2024-12-17 | 35SS+1d | 129d |  | Calendario Ma y J | Brigada Ligera 1 A; Brigada Ligera 2 B; Brigada Ligera 3 C | 126h | 22días | 112 |
| 37 | 1.3.2.4 | Retenidas | 8d | 2024-11-28 | 2024-12-24 | 35SS+2d | 127d |  | Calendario Ma y J | Canasto 1 A; Brigada Ligera 4 D; Brigada Ligera 5 E | 144h | 27días | 156 |
| 38 | 1.3.2.5 | Armados MT y BT | 5d | 2024-12-05 | 2024-12-19 | 35SS+4d | 0d |  | Calendario Ma y J | Canasto 2 B; Canasto 3 C; Canasto 4 D; Canasto 5 E; Canasto 6 F; Canasto 7 G | 180h | 15días | 224 |
| 39 | 1.3.2.6 | Tendido de Conductor MT y BT | 8d | 2024-12-24 | 2025-01-16 | 38 | 0d |  | Calendario Ma y J | Canasto 2 B; Canasto 3 C; Canasto 4 D; Canasto 5 E; Canasto 6 F; Canasto 7 G; Canasto 8 H | 336h | 24días | 19,260 |
| 40 | 1.3.2.7 | Puesta a Tierra | 3d | 2025-01-23 | 2025-01-30 | 39 | 112d | 0d | Calendario Ma y J | Canasto 1 A; Canasto 2 B; Canasto 3 C; Canasto 4 D | 72h | 8días | 115 |
| 41 | 1.3.2.8 | Conexiones y Jumper | 4d | 2025-01-23 | 2025-02-04 | 39 | 0d |  | Calendario Ma y J | Canasto 5 E; Canasto 6 F; Canasto 7 G; Canasto 8 H | 96h | 13días | 149 |
| 42 | 1.3.2.9 | Transformadores | 4d | 2025-02-04 | 2025-02-13 | 40 | 112d | 0d | Calendario Ma y J | Grúa 1 A; Grúa 2 B; Canasto 1 A; Canasto 2 B | 96h | 10días | 24 |
| 43 | 1.3.2.10 | Alumbrado Público | 3d | 2025-02-11 | 2025-02-18 | 41FS+1d | 0d |  | Calendario Ma y J | Canasto 5 E; Canasto 6 F; Canasto 7 G; Canasto 8 H; Canasto 4 D | 90h | 8días | 216 |
| 44 | 1.3.2.11 | Etiquetas CT | 1d | 2025-02-18 | 2025-02-18 | 42 | 112d |  | Calendario Ma y J | Canasto 1 A; Canasto 2 B | 12h | 1días | 25 |
| 45 | 1.3.2.12 | Totalizadores | 4d | 2025-02-20 | 2025-03-06 | 43 | 45d | 0d | Calendario Ma y J | Canasto 3 C; Canasto 4 D | 48h | 15días | 25 |
| 46 | 1.3.2.13 | Acometida | 53d | 2025-02-25 | 2025-09-09 | 45SS+1d | 45d | 0d | Calendario Ma y J | Brigada de Normalización 2 B; Brigada de Normalización 1 A | 636h | 197días | 2,121 |
| 47 | 1.3.2.14 | Remoción | 11d | 2025-09-18 | 2025-10-23 | 46FS+2d | 45d |  | Calendario Ma y J | Grúa 1 A; Canasto 1 A; Canasto 2 B; Grúa 2 B | 264h | 36días | 541 |
| 49 | 1.3.3 | **Poligono 3** | 196d | 2024-12-17 | 2026-04-14 |  | 0d |  |  |  | 12984h | 484días |  |
| 50 | 1.3.3.1 | Excavaciones | 18d | 2024-12-27 | 2025-02-10 | 18FS+1d | 170d | 0d |  | Hoyero 4; Hoyero 5; Hoyero 6; Hoyero 7; Hoyero 8; Hoyero 9; Hoyero 10; Hoyero 1; Hoyero 2; Hoyero 3; Hoyero 11; Hoyero 12; Hoyero 13; Hoyero 14; Hoyero 15 | 1620h | 46días | 1,107 |
| 51 | 1.3.3.2 | Izado de postes | 21d | 2024-12-27 | 2025-02-17 | 50SS | 170d | 0d |  | Grúa 3; Grúa 4; Grúa 5; Grúa 2; Grúa 1 | 630h | 53días | 749 |
| 52 | 1.3.3.3 | Cimentaciones | 7d | 2025-02-05 | 2025-02-19 | 51SS+15d | 170d |  |  | Brigada Ligera 1; Brigada Ligera 2 | 84h | 15días | 67 |
| 53 | 1.3.3.4 | Retenidas | 12d | 2025-03-28 | 2025-04-25 | 27 | 143d |  |  | Brigada Ligera 3; Brigada Ligera 4; Brigada Ligera 5; Canasto 5 | 288h | 29días | 358 |
| 54 | 1.3.3.5 | Armados MT y BT | 20d | 2025-04-04 | 2025-05-21 | 29 | 23d | 0d |  | Canasto 1; Canasto 2; Canasto 4; Canasto 3; Canasto 6 | 600h | 48días | 784 |
| 55 | 1.3.3.6 | Tendido de Conductor MT y BT | 29d | 2025-05-23 | 2025-07-28 | 54 | 23d | 0d |  | Canasto 1; Canasto 2; Canasto 3; Canasto 4; Canasto 5; Canasto 6 | 1044h | 67días | 60,258 |
| 56 | 1.3.3.7 | Puesta a Tierra | 13d | 2025-06-11 | 2025-07-09 | 55SS+8d | 111d |  |  | Canasto 7; Canasto 8 | 156h | 29días | 391 |
| 57 | 1.3.3.8 | Conexiones y Jumper | 13d | 2025-07-30 | 2025-08-27 | 55 | 23d | 0d |  | Canasto 1; Canasto 2; Canasto 3 | 234h | 29días | 384 |
| 58 | 1.3.3.9 | Transformadores | 8d | 2025-08-13 | 2025-08-29 | 57SS+6d | 23d | 0d |  | Grúa 3; Grúa 2; Canasto 4; Canasto 5; Canasto 6; Grúa 1 | 288h | 17días | 74 |
| 59 | 1.3.3.10 | Alumbrado Público | 16d | 2025-08-29 | 2025-10-06 | 57 | 74d |  |  | Canasto 1; Canasto 2; Canasto 3 | 288h | 39días | 728 |
| 60 | 1.3.3.11 | Etiquetas CT | 2d | 2025-09-01 | 2025-09-03 | 58 | 23d | 0d |  | Canasto 4; Canasto 5; Canasto 6 | 36h | 3días | 79 |
| 61 | 1.3.3.12 | Totalizadores | 13d | 2025-09-05 | 2025-10-06 | 60 | 23d | 0d |  | Canasto 4; Canasto 5 | 156h | 32días | 79 |
| 62 | 1.3.3.13 | Acometida | 63d | 2025-09-08 | 2026-02-13 | 61SS+1d | 23d | 0d |  | Brigada de Normalización 2; Brigada de Normalización 1 | 756h | 159días | 2,525 |
| 63 | 1.3.3.14 | Remoción | 18d | 2025-11-21 | 2026-01-05 | 62SS+30d | 38d |  |  | Canasto 2; Canasto 1; Grúa 2; Grúa 1 | 432h | 46días | 1,803 |

Notes:
- 35: No se le asigna canasto, pero requiere uno para apertura y cierre de seccionador
- 39: Con una grua es suficiente para darle apoyo a los canastos.
- 51: No se le asigna canasto, pero requiere uno para apertura y cierre de seccionador
- 55: Con una grua es suficiente para darle apoyo a los canastos.

| ID | WBS | Task | Duration | Start | Finish | Predecessors | Total slack | Free slack | Calendar | Resources | Work | Días Calendario | Cantidad |
| --- | --- | --- | --- | --- | --- | --- | --- | --- | --- | --- | --- | --- | --- |
| 65 | 1.3.3.15 | **Poligono 4** | 130d | 2024-12-17 | 2026-04-14 |  | 0d |  | Calendario Ma y J |  | 6372h | 484días |  |
| 66 | 1.3.3.15.1 | Excavaciones | 27d | 2024-12-17 | 2025-03-25 | 34FS+1d | 103d | 0d | Calendario Ma y J | Hoyero 3 C; Hoyero 4 D; Hoyero 5 E; Hoyero 6 F; Hoyero 7 G; Hoyero 8 H; Hoyero 9 I; Hoyero 10 J; Hoyero 1 A; Hoyero 2 B | 1620h | 99días | 1,072 |
| 67 | 1.3.3.15.2 | Izado de postes | 27d | 2024-12-17 | 2025-03-25 | 66SS | 103d | 0d | Calendario Ma y J | Grúa 4 D; Grúa 5 E; Grúa 3 C | 486h | 99días | 575 |
| 68 | 1.3.3.15.3 | Cimentaciones | 14d | 2025-02-04 | 2025-03-25 | 67SS+13d | 103d |  | Calendario Ma y J | Brigada Ligera 1 A; Brigada Ligera 2 B | 168h | 50días | 140 |
| 69 | 1.3.3.15.4 | Retenidas | 17d | 2025-02-20 | 2025-04-24 | 43 | 95d |  | Calendario Ma y J | Brigada Ligera 4 D; Brigada Ligera 5 E; Brigada Ligera 3 C; Canasto 1 A | 408h | 64días | 497 |
| 70 | 1.3.3.15.5 | Armados MT y BT | 21d | 2025-02-25 | 2025-05-15 | 43FS+1d | 0d |  | Calendario Ma y J | Canasto 5 E; Canasto 7 G; Canasto 8 H; Canasto 6 F | 504h | 80días | 663 |
| 71 | 1.3.3.15.6 | Tendido de Conductor MT y BT | 15d | 2025-05-20 | 2025-07-10 | 70 | 0d |  | Calendario Ma y J | Canasto 3 C; Canasto 4 D; Canasto 5 E; Canasto 1 A; Canasto 2 B; Canasto 6 F; Canasto 7 G; Canasto 8 H | 720h | 52días | 42,712 |
| 72 | 1.3.3.15.7 | Puesta a Tierra | 10d | 2025-07-15 | 2025-08-14 | 71 | 57d | 0d | Calendario Ma y J | Canasto 3 C; Canasto 4 D; Canasto 1 A; Canasto 2 B | 240h | 31días | 402 |
| 73 | 1.3.3.15.8 | Conexiones y Jumper | 11d | 2025-07-15 | 2025-08-19 | 71 | 0d |  | Calendario Ma y J | Canasto 5 E; Canasto 6 F; Canasto 7 G; Canasto 8 H | 264h | 36días | 421 |
| 74 | 1.3.3.15.9 | Transformadores | 6d | 2025-08-19 | 2025-09-04 | 72 | 57d | 0d | Calendario Ma y J | Grúa 1 A; Canasto 1 A; Canasto 2 B; Grúa 2 B; Canasto 3 C; Grúa 3 C | 216h | 17días | 57 |
| 75 | 1.3.3.15.10 | Alumbrado Público | 7d | 2025-08-21 | 2025-09-11 | 73 | 0d |  | Calendario Ma y J | Canasto 4 D; Canasto 5 E; Canasto 6 F; Canasto 7 G; Canasto 8 H | 210h | 22días | 536 |
| 76 | 1.3.3.15.11 | Etiquetas CT | 2d | 2025-09-09 | 2025-09-11 | 74 | 57d |  | Calendario Ma y J | Canasto 1 A; Canasto 2 B | 24h | 3días | 66 |
| 77 | 1.3.3.15.12 | Totalizadores | 6d | 2025-09-16 | 2025-10-02 | 75 | 0d |  | Calendario Ma y J | Canasto 3 C; Canasto 4 D; Canasto 5 E; Canasto 6 F | 144h | 17días | 66 |
| 78 | 1.3.3.15.13 | Acometida | 56d | 2025-09-18 | 2026-04-14 | 77SS+1d | 0d |  | Calendario Ma y J | Brigada de Normalización 2 B; Brigada de Normalización 1 A | 672h | 209días | 2,227 |
| 79 | 1.3.3.15.14 | Remoción | 29d | 2025-11-11 | 2026-02-26 | 78SS+15d | 12d |  | Calendario Ma y J | Grúa 1 A; Canasto 1 A; Canasto 2 B; Grúa 2 B | 696h | 108días | 1,438 |

Notes:
- 67: No se le asigna canasto, pero requiere uno para apertura y cierre de seccionador
- 71: Con una grua es suficiente para darle apoyo a los canastos.
